Schedule from GanttProject, 2024-02-22 to 2025-04-23.
Holidays every year on 01-01, 03-05, 05-01, 05-08, 07-14, 08-15, 11-01, 11-11, 12-25

## Calendars

- Project calendar: Mon-Fri working; Sat-Sun off. Exceptions (off unless hours are given): 2024-03-05, 2024-04-01 (Lundi de Pâques), 2024-05-09 (Ascension), 2024-05-20 (Lundi de Pentecôte), 2024-06-06 (Vacances sur 06/06/2024 00:00), 2024-06-18 (Vacances sur 18/06/2024 00:00), 2024-12-16 (Vacances sur 16/12/2024 00:00), 2024-12-17 (Vacances sur 17/12/2024 00:00), 2024-12-18 (Vacances sur 18/12/2024 00:00), 2024-12-19 (Vacances sur 19/12/2024 00:00), 2024-12-20 (Vacances sur 20/12/2024 00:00), 2024-12-23 (Vacances sur 23/12/2024 00:00), 2024-12-24 (Vacances sur 24/12/2024 00:00), 2024-12-26 (Vacances sur 26/12/2024 00:00), 2024-12-27 (Vacances sur 27/12/2024 00:00), 2024-12-30 (Vacances sur 30/12/2024 00:00), 2024-12-31 (Vacances sur 31/12/2024 00:00), 2025-01-02 (Vacances sur 02/01/2025 00:00), 2025-01-03 (Vacances sur 03/01/2025 00:00), 2025-04-21 (Lundi de Pâques).

## Schedule

| ID | WBS | Task | Type | Duration | Start | Finish | Predecessors | Complete |
| --- | --- | --- | --- | --- | --- | --- | --- | --- |
| 1 | 1 | **BET structure** |  | 35d | 2024-02-22 | 2024-04-12 |  |  |
| 2 | 1.1 | Etude d'exécutions coffrages / ferraillages platines de l'ensemble du gros oeuvre |  | 35d | 2024-02-22 | 2024-04-12 |  |  |
| 3 | 2 | **Installation de chantier et implantation** |  | 2d | 2024-04-15 | 2024-04-16 |  |  |
| 4 | 2.1 | Mise en place des chaises de niveau |  | 2d | 2024-04-15 | 2024-04-16 |  |  |
| 5 | 3 | Test de sol géotechnique | milestone | 0d | 2024-04-15 | 2024-04-15 |  |  |
| 6 | 4 | VRD (aménagement) | milestone | 0d | 2024-04-15 | 2024-04-15 |  |  |
| 7 | 5 | **Fondations** |  | 72d | 2024-04-17 | 2024-08-02 | 3 | 40% |
| 8 | 5.1 | Fouilles de fondations |  | 5d | 2024-04-17 | 2024-04-23 | 4 | 100% |
| 9 | 5.2 | béton de propreté ép : 5 cm |  | 5d | 2024-04-24 | 2024-04-30 | 8 | 100% |
| 10 | 5.3 | Ferraillage : confection et mise en oeuvre |  | 10d | 2024-05-02 | 2024-05-17 | 9 | 100% |
| 11 | 5.4 | Semelles filante |  | 5d | 2024-05-21 | 2024-05-27 | 10 | 100% |
| 12 | 5.5 | Longrines de fondation |  | 32d | 2024-05-28 | 2024-07-12 | 11 |  |
| 13 | 5.6 | Remblai sous hérisson | milestone | 0d | 2024-07-22 | 2024-07-22 | 12FS+5d |  |
| 14 | 5.7 | Hérisson ventilé ép : 15 cm |  | 5d | 2024-07-29 | 2024-08-02 | 13FS+5d |  |
| 15 | 6 | **Traitement anti-termites** |  | 26d | 2024-06-05 | 2024-07-12 |  |  |
| 16 | 6.1 | Traitement des nuisible par aspersion | milestone | 0d | 2024-06-05 | 2024-06-05 |  | 100% |
| 17 | 6.2 | Traitement anti-termites par termigranul | milestone | 0d | 2024-07-15 | 2024-07-15 | 12 |  |
| 18 | 6.3 | Traitement par termifuges pour planelles | milestone | 0d | 2024-07-15 | 2024-07-15 | 12 |  |
| 19 | 7 | Electricité (réservation) |  | 2d | 2024-07-22 | 2024-07-23 | 13 |  |
| 20 | 8 | Plomberie (réservation) |  | 2d | 2024-07-24 | 2024-07-25 | 1, 19 |  |
| 21 | 9 | Raccordement assainissement |  | 5d | 2024-08-27 | 2024-09-02 |  |  |
| 22 | 10 | **Elévation RDC** |  | 20d | 2024-09-04 | 2024-10-01 | 21 |  |
| 23 | 10.1 | Voile en béton armé |  | 4d | 2024-09-04 | 2024-09-09 |  |  |
| 24 | 10.2 | Chaînages verticaux |  | 4d | 2024-09-10 | 2024-09-13 | 23 |  |
| 25 | 10.3 | Chaînages horizentaux |  | 4d | 2024-09-16 | 2024-09-19 | 24 |  |
| 26 | 10.4 | Linteaux |  | 4d | 2024-09-20 | 2024-09-25 | 25 |  |
| 27 | 10.5 | Poutres en béton armé |  | 5d | 2024-09-20 | 2024-09-26 | 26SS |  |
| 28 | 10.6 | Escalier en béton armé |  | 3d | 2024-09-27 | 2024-10-01 | 27 |  |
| 29 | 11 | Dalle en béton armé R+1 |  | 20d | 2024-10-02 | 2024-10-29 | 22 |  |

| ID | WBS | Task | Duration | Start | Finish | Predecessors |
| --- | --- | --- | --- | --- | --- | --- |
| 30 | 12 | **Elévation R+1** | 20d | 2024-10-30 | 2024-11-28 | 29 |
| 31 | 12.1 | Voile en béton armé | 5d | 2024-10-30 | 2024-11-06 |  |
| 32 | 12.2 | Chaînages verticaux | 5d | 2024-11-07 | 2024-11-14 | 31 |
| 33 | 12.3 | Chaînages horizentaux | 5d | 2024-11-15 | 2024-11-21 | 32 |
| 34 | 12.4 | Linteaux | 5d | 2024-11-22 | 2024-11-28 | 33 |
| 35 | 12.5 | Gouttes d'eaux | 5d | 2024-11-22 | 2024-11-28 | 34SS |
| 36 | 13 | **Enduit & peinture RDC** | 25d | 2024-11-29 | 2025-01-23 | 35 |
| 37 | 13.1 | Mur enduit Ext / Int | 5d | 2024-11-29 | 2024-12-05 |  |
| 38 | 13.2 | Mur enduit Int / Int | 5d | 2024-12-06 | 2024-12-12 | 37 |
| 39 | 13.3 | Plafond enduit Ext / Int | 5d | 2024-12-13 | 2025-01-09 | 38 |
| 40 | 13.4 | Peinture intérieur sur mur enduit | 5d | 2025-01-10 | 2025-01-16 | 39 |
| 41 | 13.5 | Peinture intérieur sur plafond enduit | 5d | 2025-01-17 | 2025-01-23 | 40 |
| 42 | 13.6 | Peinture extérieur sur mur enduit | 5d | 2024-12-06 | 2024-12-12 | 37 |
| 43 | 13.7 | Peinture extérieur sur plafond enduit | 5d | 2025-01-10 | 2025-01-16 | 39 |
| 44 | 14 | Plâtrerie RDC | 10d | 2025-01-17 | 2025-01-30 | 43 |
| 45 | 15 | Revêtement de sol RDC | 1d | 2025-01-24 | 2025-01-24 | 36 |
| 46 | 16 | **Enduit & peinture R+1** | 22d | 2025-01-27 | 2025-02-25 | 45 |
| 47 | 16.1 | Mur enduit Ext / Int | 6d | 2025-01-27 | 2025-02-03 | 45 |
| 48 | 16.2 | Mur enduit Int / Int | 6d | 2025-02-04 | 2025-02-11 | 47 |
| 49 | 16.3 | Peinture intérieur sur mur enduit | 10d | 2025-02-12 | 2025-02-25 | 48 |
| 50 | 17 | Plafonds extérieur en placoplâtre standard | 6d | 2024-11-20 | 2024-11-27 |  |
| 51 | 18 | Revêtement de sol R+1 | 25d | 2024-11-20 | 2025-01-14 |  |
| 52 | 19 | Menuiseries bois | 10d | 2025-01-15 | 2025-01-28 | 51 |
| 53 | 20 | Plomberie (appareillages) | 1d | 2025-01-29 | 2025-01-29 | 52 |
| 54 | 21 | Electricité (appareillages) | 10d | 2025-01-29 | 2025-02-11 | 52 |
| 55 | 22 | Peinture extérieur | 15d | 2025-02-26 | 2025-03-19 | 46 |

| ID | WBS | Task | Type | Duration | Start | Finish | Predecessors |
| --- | --- | --- | --- | --- | --- | --- | --- |
| 56 | 23 | **Plâtrerie R+1** |  | 12d | 2025-03-20 | 2025-04-04 | 55 |
| 57 | 23.1 | Plafonds intérieur en placoplâtre hydrofuge coupe-feu |  | 6d | 2025-03-20 | 2025-03-27 | 55 |
| 58 | 23.2 | Plafonds des salles de bain en placoplâtre hydrofuge |  | 6d | 2025-03-28 | 2025-04-04 | 57 |
| 59 | 24 | Huisserie aluminium |  | 10d | 2025-01-29 | 2025-02-11 | 52 |
| 60 | 25 | Cuisine |  | 10d | 2025-01-29 | 2025-02-11 | 59SS |
| 61 | 26 | **Charpente & couverture** |  | 15d | 2024-11-29 | 2025-01-09 | 35 |
| 62 | 26.1 | Dallage en béton armé RDC |  | 15d | 2024-11-29 | 2025-01-09 | 14 |
| 63 | 27 | Climatisation |  | 5d | 2025-02-26 | 2025-03-04 | 46 |
| 64 | 28 | Jardins |  | 10d | 2025-04-03 | 2025-04-16 | 60FS+35d |
| 65 | 29 | Replis du chantier |  | 10d | 2025-04-08 | 2025-04-22 | 64SS+3d |
| 66 | 30 | OPR | milestone | 0d | 2025-04-23 | 2025-04-23 | 65 |
